# LCGT_IOOO_20111125

Schedule from MS Project, 2011-04-01 to 2014-06-30.
Dell

## Calendars

- 標準: Mon-Fri 08:00-12:00, 13:00-17:00; Sat-Sun off.

## Schedule

| ID | WBS | Task | Type | Duration | Start | Finish | Total slack | Constraint |
| --- | --- | --- | --- | --- | --- | --- | --- | --- |
| 1 | 1 | Tunnel | manual | 1d | 2014-03-31 | 2014-03-31 |  |  |
| 2 | 2 | **Preparing IO opticses** |  | 522d | 2011-04-01 | 2013-03-31 |  |  |
| 3 | 2.1 | Pre Mode Cleaner | manual | 135d | 2011-11-25 | 2012-05-31 |  |  |
| 4 | 2.2 | Isorator in vac. | manual | 135d | 2011-11-25 | 2012-05-31 |  |  |
| 5 | 2.3 | Regid Cavity | manual | 132d | 2012-04-01 | 2012-09-30 |  |  |
| 6 | 2.4 | Green Laser | manual | 132d | 2012-04-01 | 2012-09-30 |  |  |
| 7 | 2.5 | Buy all optics 2011 | manual | 92d | 2011-11-25 | 2012-03-31 |  |  |
| 8 | 2.6 | Buy all optics 2012 | manual | 262d | 2012-04-01 | 2013-03-31 |  |  |
| 9 | 3 | **Laser Room** |  | 1d | 2014-03-31 | 2014-03-31 |  |  |
| 10 | 3.1 | Cleanness | manual | 1d? | 2014-03-31 | 2014-03-31 |  |  |
| 11 | 3.2 | Temperture | manual | 1d? | 2014-03-31 | 2014-03-31 |  |  |
| 12 | 3.3 | Optical table | manual | 1d? | 2014-03-31 | 2014-03-31 |  |  |
| 13 | 4 | **Install IOO Sysytem** |  | 65d | 2014-04-01 | 2014-06-30 |  |  |
| 14 | 4.1 | **Input optics system** |  | 65d | 2014-04-01 | 2014-06-30 | 0d |  |
| 15 | 4.1.1 | on Input optics table | manual | 14d | 2014-04-01 | 2014-04-18 |  | start no earlier than 2014-04-01 |
| 16 | 4.1.2 | Regid Cavity | manual | 26d | 2014-05-26 | 2014-06-30 |  |  |
| 17 | 4.2 | **Mode Cleaner** |  | 51d | 2014-04-21 | 2014-06-30 |  |  |
| 18 | 4.2.1 | MC mirror and pendlum install | manual | 8d | 2014-04-21 | 2014-04-30 |  | finish no earlier than 2014-04-30 |
| 19 | 4.2.2 | MC cavity lock | manual | 9d | 2014-05-06 | 2014-05-16 |  | finish no earlier than 2014-05-16 |
| 20 | 4.2.3 | MC alignment contraol | manual | 26d | 2014-05-26 | 2014-06-30 |  | finish no earlier than 2014-06-30 |
| 21 | 4.3 | **Isorator in vac** |  | 5d | 2014-05-19 | 2014-05-23 |  |  |
| 22 | 4.3.1 | Install | manual | 5d | 2014-05-19 | 2014-05-23 |  | finish no earlier than 2014-05-23 |
| 24 | 5 | Iso.のインストール完了で、干渉計に光を通せる。 | manual | 1d? | 2011-11-25 | 2011-11-25 |  |  |
| 25 | 6 | **約２ヶ月でMCの後ろに光を通すことが可能。** |  | 1d? | 2011-11-25 | 2011-11-25 |  |  |
| 26 | 6.1 | 前提：レーザールームが完成していること。 | manual | 1d? | 2011-11-25 | 2011-11-25 |  |  |
| 27 | 6.2 | 前提：センタールームのクリーン環境が完成していること。 | manual | 1d? | 2011-11-25 | 2011-11-25 |  |  |
| 28 | 6.3 | 前提：MCの真空タンクが設置されてること。 | manual | 1d? | 2011-11-25 | 2011-11-25 |  |  |
| 29 | 6.4 | 前提：MCの防振系に問題ないこと。 | manual | 1d? | 2011-11-25 | 2011-11-25 |  |  |
| 30 | 6.5 | 前提：十分な人員が確保されてること。必要な人が神岡にいること。 | manual | 1d? | 2011-11-25 | 2011-11-25 |  |  |
| 31 | 7 | MCのアライメントコントロール、および、リジットキャビティーによる低周波安定化は、それ以降。 | manual | 1d? | 2011-11-25 | 2011-11-25 |  |  |

Notes:
- 13: It will be available of an installation for main interferometer after finish of 'Isorator invac'.
